# Harmonogram V5523

Schedule from MS Project, 2017-08-07 to 2018-06-06.

## Calendars

- Štandardný: Mon-Fri 08:00-12:00, 13:00-17:00; Sat-Sun off. Exceptions (off unless hours are given): 2017-08-12 to 2017-08-13 08:00-12:00, 13:00-17:00 (10), 2017-08-19 to 2017-08-20 08:00-12:00, 13:00-17:00 (10), 2017-08-26 to 2017-08-27 08:00-12:00, 13:00-17:00 (10), 2017-09-02 to 2017-09-03 08:00-12:00, 13:00-17:00 (10), 2017-09-09 to 2017-09-10 08:00-12:00, 13:00-17:00 (10), 2017-09-16 to 2017-09-17 08:00-12:00, 13:00-17:00 (10), 2017-09-23 to 2017-09-24 08:00-12:00, 13:00-17:00 (10), 2017-09-30 to 2017-10-01 08:00-12:00, 13:00-17:00 (10), 2017-10-07 to 2017-10-08 08:00-12:00, 13:00-17:00 (10), 2017-10-14 to 2017-10-15 08:00-12:00, 13:00-17:00 (10), 2017-10-21 to 2017-10-22 08:00-12:00, 13:00-17:00 (10), 2017-10-28 to 2017-10-29 08:00-12:00, 13:00-17:00 (10), 2017-11-04 to 2017-11-05 08:00-12:00, 13:00-17:00 (10), 2017-11-11 to 2017-11-12 08:00-12:00, 13:00-17:00 (10), 2017-11-18 to 2017-11-19 08:00-12:00, 13:00-17:00 (10), 2017-11-25 to 2017-11-26 08:00-12:00, 13:00-17:00 (10), 2017-12-02 to 2017-12-03 08:00-12:00, 13:00-17:00 (10), 2017-12-09 to 2017-12-10 08:00-12:00, 13:00-17:00 (10), 2017-12-16 to 2017-12-17 08:00-12:00, 13:00-17:00 (10), 2017-12-23 to 2017-12-24 08:00-12:00, 13:00-17:00 (10), 2017-12-30 to 2017-12-31 08:00-12:00, 13:00-17:00 (10), 2018-01-06 to 2018-01-07 08:00-12:00, 13:00-17:00 (10), 2018-01-13 to 2018-01-14 08:00-12:00, 13:00-17:00 (10), 2018-01-20 to 2018-01-21 08:00-12:00, 13:00-17:00 (10), 2018-01-27 to 2018-01-28 08:00-12:00, 13:00-17:00 (10), 2018-02-03 to 2018-02-04 08:00-12:00, 13:00-17:00 (10), 2018-02-10 to 2018-02-11 08:00-12:00, 13:00-17:00 (10), 2018-02-17 to 2018-02-18 08:00-12:00, 13:00-17:00 (10), 2018-02-24 to 2018-02-25 08:00-12:00, 13:00-17:00 (10), 2018-03-03 to 2018-03-04 08:00-12:00, 13:00-17:00 (10), 2018-03-10 to 2018-03-11 08:00-12:00, 13:00-17:00 (10), 2018-03-17 to 2018-03-18 08:00-12:00, 13:00-17:00 (10), 2018-03-24 to 2018-03-25 08:00-12:00, 13:00-17:00 (10), 2018-03-31 to 2018-04-01 08:00-12:00, 13:00-17:00 (10), 2018-04-07 to 2018-04-08 08:00-12:00, 13:00-17:00 (10), 2018-04-14 to 2018-04-15 08:00-12:00, 13:00-17:00 (10), 2018-04-21 to 2018-04-22 08:00-12:00, 13:00-17:00 (10), 2018-04-28 to 2018-04-29 08:00-12:00, 13:00-17:00 (10), 2018-05-05 to 2018-05-06 08:00-12:00, 13:00-17:00 (10), 2018-05-12 to 2018-05-13 08:00-12:00, 13:00-17:00 (10), 2018-05-19 to 2018-05-20 08:00-12:00, 13:00-17:00 (10), 2018-05-26 to 2018-05-27 08:00-12:00, 13:00-17:00 (10), 2018-06-02 to 2018-06-03 08:00-12:00, 13:00-17:00 (10).

## Schedule

| ID | WBS | Task | Type | Duration | Start | Finish | Predecessors | Total slack | Free slack | Constraint |
| --- | --- | --- | --- | --- | --- | --- | --- | --- | --- | --- |
| 1 | 1 | **V 5522 Výmena vedení 110kV** |  | 304d? | 2017-08-07 | 2018-06-06 |  | 0d |  |  |
| 2 | 1.1 | Zařízení staveniště/přístupové cesty | manual | 4d | 2017-08-07 | 2017-08-10 |  |  |  |  |
| 3 | 1.2 | **Demontážní práce** |  | 48d | 2017-08-11 | 2017-09-27 |  | 0d |  |  |
| 4 | 1.2.1 | **p.b.25 - p.b.26** |  | 1d | 2017-08-11 | 2017-08-11 |  | 0d |  |  |
| 5 | 1.2.1.1 | Demontáž vodičů | manual | 1d | 2017-08-11 | 2017-08-11 | 2 |  |  |  |
| 6 | 1.2.2 | **p.b.26 - p.b.40** |  | 3d | 2017-08-11 | 2017-08-13 |  | 0d |  |  |
| 7 | 1.2.2.1 | Demontáž vodičů | manual | 1d | 2017-08-11 | 2017-08-11 | 5SS |  |  |  |
| 8 | 1.2.2.2 | Demontáž stožárů a základů | manual | 2d | 2017-08-12 | 2017-08-13 | 7 |  |  |  |
| 9 | 1.2.3 | **p.b.40 - p.b.52** |  | 3d | 2017-08-14 | 2017-08-16 |  | 0d |  |  |
| 10 | 1.2.3.1 | Demontáž vodičů | manual | 1d | 2017-08-14 | 2017-08-14 | 8 |  |  |  |
| 11 | 1.2.3.2 | Demontáž stožárů a základů | manual | 2d | 2017-08-15 | 2017-08-16 | 10 |  |  |  |
| 12 | 1.2.4 | **p.b.52 - p.b.59** |  | 3d | 2017-08-21 | 2017-08-23 |  | 1d |  |  |
| 13 | 1.2.4.1 | Demontáž vodičů |  | 1d | 2017-08-21 | 2017-08-21 | 11FS+4d | 140d | 0d | start no earlier than 2017-08-07 |
| 14 | 1.2.4.2 | Demontáž stožárů a základů | manual | 2d | 2017-08-22 | 2017-08-23 | 13 |  |  |  |
| 15 | 1.2.5 | **p.b.59 - p.b.69** |  | 3d | 2017-08-24 | 2017-08-26 |  | 0d |  |  |
| 16 | 1.2.5.1 | Demontáž vodičů | manual | 1d | 2017-08-24 | 2017-08-24 | 14 |  |  |  |
| 17 | 1.2.5.2 | Demontáž stožárů a základů | manual | 2d | 2017-08-25 | 2017-08-26 | 16 |  |  |  |
| 18 | 1.2.6 | **p.b.69 - p.b.80** |  | 4d | 2017-08-27 | 2017-08-30 |  | 0d |  |  |
| 19 | 1.2.6.1 | Demontáž vodičů | manual | 1d | 2017-08-27 | 2017-08-27 | 17 |  |  |  |
| 20 | 1.2.6.2 | Demontáž stožárů a základů | manual | 3d | 2017-08-28 | 2017-08-30 | 19 |  |  |  |
| 21 | 1.2.7 | **p.b.80 - p.b.92** |  | 4d | 2017-09-04 | 2017-09-07 |  | 0d |  |  |
| 22 | 1.2.7.1 | Demontáž vodičů | manual | 1d | 2017-09-04 | 2017-09-04 | 20FS+4d |  |  |  |
| 23 | 1.2.7.2 | Demontáž stožárů a základů | manual | 3d | 2017-09-05 | 2017-09-07 | 22 |  |  |  |
| 24 | 1.2.8 | **p.b.92 - p.b.104** |  | 3d | 2017-09-08 | 2017-09-10 |  | 0d |  |  |
| 25 | 1.2.8.1 | Demontáž vodičů | manual | 1d | 2017-09-08 | 2017-09-08 | 23 |  |  |  |
| 26 | 1.2.8.2 | Demontáž stožárů a základů | manual | 2d | 2017-09-09 | 2017-09-10 | 25 |  |  |  |

| ID | WBS | Task | Type | Duration | Start | Finish | Predecessors | Total slack |
| --- | --- | --- | --- | --- | --- | --- | --- | --- |
| 27 | 1.2.9 | **p.b.104 - p.b.112** |  | 3d | 2017-09-11 | 2017-09-13 |  | 0d |
| 28 | 1.2.9.1 | Demontáž vodičů | manual | 1d | 2017-09-11 | 2017-09-11 | 26 |  |
| 29 | 1.2.9.2 | Demontáž stožárů a základů | manual | 2d | 2017-09-12 | 2017-09-13 | 28 |  |
| 30 | 1.2.10 | **p.b.112 - p.b.131** |  | 5d | 2017-08-11 | 2017-08-15 |  | 0d |
| 31 | 1.2.10.1 | Demontáž vodičů | manual | 2d | 2017-08-11 | 2017-08-12 | 2 |  |
| 32 | 1.2.10.2 | Demontáž stožárů a základů | manual | 3d | 2017-08-13 | 2017-08-15 | 31 |  |
| 33 | 1.2.11 | **p.b.131 - p.b.142** |  | 7d | 2017-08-16 | 2017-08-22 |  | 0d |
| 34 | 1.2.11.1 | Demontáž vodičů | manual | 1d | 2017-08-16 | 2017-08-16 | 32 |  |
| 35 | 1.2.11.2 | Demontáž stožárů a základů | manual | 2d | 2017-08-21 | 2017-08-22 | 34 |  |
| 36 | 1.2.12 | **p.b.142 - p.b.155** |  | 3d | 2017-08-23 | 2017-08-25 |  | 0d |
| 37 | 1.2.12.1 | Demontáž vodičů | manual | 1d | 2017-08-23 | 2017-08-23 | 35 |  |
| 38 | 1.2.12.2 | Demontáž stožárů a základů | manual | 2d | 2017-08-24 | 2017-08-25 | 37 |  |
| 39 | 1.2.13 | **p.b.155 - p.b.165** |  | 4d | 2017-08-26 | 2017-08-29 |  | 0d |
| 40 | 1.2.13.1 | Demontáž vodičů | manual | 1d | 2017-08-26 | 2017-08-26 | 38 |  |
| 41 | 1.2.13.2 | Demontáž stožárů a základů | manual | 2d | 2017-08-28 | 2017-08-29 | 40 |  |
| 42 | 1.2.14 | **p.b.165 - p.b.168** |  | 1d | 2017-08-30 | 2017-08-30 |  | 0d |
| 43 | 1.2.14.1 | Demontáž vodičů | manual | 1d | 2017-08-30 | 2017-08-30 | 41 |  |
| 44 | 1.2.14.2 | Demontáž stožárů a základů | manual | 1d | 2017-08-30 | 2017-08-30 | 43SS |  |
| 45 | 1.2.15 | **p.b.168 - p.b.176** |  | 3d | 2017-09-04 | 2017-09-06 |  | 0d |
| 46 | 1.2.15.1 | Demontáž vodičů | manual | 1d | 2017-09-04 | 2017-09-04 | 44SS+4d |  |
| 47 | 1.2.15.2 | Demontáž stožárů a základů | manual | 2d | 2017-09-05 | 2017-09-06 | 46 |  |
| 48 | 1.2.16 | **p.b.176 - p.b.185** |  | 3d | 2017-09-07 | 2017-09-09 |  | 0d |
| 49 | 1.2.16.1 | Demontáž vodičů | manual | 1d | 2017-09-07 | 2017-09-07 | 47 |  |
| 50 | 1.2.16.2 | Demontáž stožárů a základů | manual | 2d | 2017-09-08 | 2017-09-09 | 49 |  |

| ID | WBS | Task | Type | Duration | Start | Finish | Predecessors | Total slack |
| --- | --- | --- | --- | --- | --- | --- | --- | --- |
| 51 | 1.2.17 | **p.b.185 - p.b.198** |  | 4d | 2017-09-10 | 2017-09-13 |  | 0d |
| 52 | 1.2.17.1 | Demontáž vodičů | manual | 1d | 2017-09-10 | 2017-09-10 | 50 |  |
| 53 | 1.2.17.2 | Demontáž stožárů a základů | manual | 3d | 2017-09-11 | 2017-09-13 | 52 |  |
| 54 | 1.2.18 | **p.b.198 - p.b.213** |  | 4d | 2017-09-18 | 2017-09-21 |  | 0d |
| 55 | 1.2.18.1 | Demontáž vodičů | manual | 1d | 2017-09-18 | 2017-09-18 | 53FS+4d |  |
| 56 | 1.2.18.2 | Demontáž stožárů a základů | manual | 3d | 2017-09-19 | 2017-09-21 | 55 |  |
| 57 | 1.2.19 | **p.b.213 - p.b.223** |  | 3d | 2017-09-22 | 2017-09-24 |  | 0d |
| 58 | 1.2.19.1 | Demontáž vodičů | manual | 1d | 2017-09-22 | 2017-09-22 | 56 |  |
| 59 | 1.2.19.2 | Demontáž stožárů a základů | manual | 2d | 2017-09-23 | 2017-09-24 | 58 |  |
| 60 | 1.2.20 | **p.b.223 - portál Telč** |  | 3d | 2017-09-25 | 2017-09-27 |  | 0d |
| 61 | 1.2.20.1 | Demontáž vodičů | manual | 1d | 2017-09-25 | 2017-09-25 | 59 |  |
| 62 | 1.2.20.2 | Demontáž stožárů a základů | manual | 2d | 2017-09-26 | 2017-09-27 | 61 |  |
| 63 | 1.3 | **Montážne práce základů a stožárů** |  | 262d | 2017-08-21 | 2018-05-09 |  | 0d |
| 64 | 1.3.1 | **p.b.26 - p.b.33** |  | 61d | 2017-08-21 | 2017-10-20 |  | 0d |
| 65 | 1.3.1.1 | Realizace základů | manual | 10d | 2017-08-21 | 2017-08-30 |  |  |
| 66 | 1.3.1.2 | Montáž OK na zemi | manual | 10d | 2017-09-18 | 2017-09-27 | 65FS+4d |  |
| 67 | 1.3.1.3 | Postavení OK | manual | 5d | 2017-10-16 | 2017-10-20 | 65FS+28d |  |
| 68 | 1.3.2 | **p.b.34 - p.b.40** |  | 52d | 2017-09-04 | 2017-10-25 |  | 0d |
| 69 | 1.3.2.1 | Realizace základů | manual | 10d | 2017-09-04 | 2017-09-13 | 65FS+4d |  |
| 70 | 1.3.2.2 | Montáž OK na zemi | manual | 10d | 2017-10-02 | 2017-10-11 | 69FS+4d, 66FS+4d |  |
| 71 | 1.3.2.3 | Postavení OK | manual | 5d | 2017-10-21 | 2017-10-25 | 69FS+28d, 67 |  |
| 72 | 1.3.3 | **p.b.41 - p.b.46** |  | 73d | 2017-09-18 | 2017-11-29 |  | 0d |
| 73 | 1.3.3.1 | Realizace základů | manual | 5d | 2017-09-18 | 2017-09-22 | 69FS+4d |  |
| 74 | 1.3.3.2 | Montáž OK na zemi | manual | 5d | 2017-10-30 | 2017-11-03 | 73 |  |
| 75 | 1.3.3.3 | Postavení OK | manual | 3d | 2017-11-27 | 2017-11-29 | 73FS+28d, 71FS+4d |  |

| ID | WBS | Task | Type | Duration | Start | Finish | Predecessors | Total slack |
| --- | --- | --- | --- | --- | --- | --- | --- | --- |
| 76 | 1.3.4 | **p.b.47 - p.b.52** |  | 71d | 2017-09-23 | 2017-12-02 |  | 0d |
| 77 | 1.3.4.1 | Realizace základů | manual | 5d | 2017-09-23 | 2017-09-27 | 73 |  |
| 78 | 1.3.4.2 | Montáž OK na zemi | manual | 5d | 2017-11-04 | 2017-11-08 | 74, 77 |  |
| 79 | 1.3.4.3 | Postavení OK | manual | 3d | 2017-11-30 | 2017-12-02 | 77FS+28d, 75 |  |
| 80 | 1.3.5 | **p.b.53 - p.b.59** |  | 66d | 2017-10-02 | 2017-12-06 |  | 0d |
| 81 | 1.3.5.1 | Realizace základů | manual | 10d | 2017-10-02 | 2017-10-11 | 77FS+4d |  |
| 82 | 1.3.5.2 | Montáž OK na zemi | manual | 10d | 2017-11-13 | 2017-11-22 | 70, 78FS+4d |  |
| 83 | 1.3.5.3 | Postavení OK | manual | 4d | 2017-12-03 | 2017-12-06 | 81FS+28d, 79 |  |
| 84 | 1.3.6 | **p.b.60 - p.b.69** |  | 90d | 2017-10-16 | 2018-01-13 |  | 0d |
| 85 | 1.3.6.1 | Realizace základů | manual | 10d | 2017-10-16 | 2017-10-25 | 81FS+4d |  |
| 86 | 1.3.6.2 | Montáž OK na zemi | manual | 10d | 2017-12-11 | 2017-12-20 | 82FS+4d |  |
| 87 | 1.3.6.3 | Postavení OK | manual | 6d | 2018-01-08 | 2018-01-13 | 85FS+28d, 83FS+4d |  |
| 88 | 1.3.7 | **p.b.70 - p.b.76** |  | 80d | 2017-10-30 | 2018-01-17 |  | 0d |
| 89 | 1.3.7.1 | Realizace základů | manual | 8d | 2017-10-30 | 2017-11-06 | 85FS+4d |  |
| 90 | 1.3.7.2 | Montáž OK na zemi | manual | 10d | 2017-12-25 | 2018-01-03 | 86FS+4d |  |
| 91 | 1.3.7.3 | Postavení OK | manual | 4d | 2018-01-14 | 2018-01-17 | 89FS+28d, 87 |  |
| 92 | 1.3.8 | **p.b.76 - p.b.80** |  | 121d | 2017-11-07 | 2018-03-07 |  | 0d |
| 93 | 1.3.8.1 | Realizace základů | manual | 6d | 2017-11-07 | 2017-11-16 | 89 |  |
| 94 | 1.3.8.2 | Montáž OK na zemi | manual | 10d | 2018-01-22 | 2018-01-31 | 93SS |  |
| 95 | 1.3.8.3 | Postavení OK | manual | 3d | 2018-03-05 | 2018-03-07 | 93FS+28d, 91 |  |
| 96 | 1.3.9 | **p.b.81 - p.b.85** |  | 114d | 2017-11-17 | 2018-03-10 |  | 0d |
| 97 | 1.3.9.1 | Realizace základů | manual | 6d | 2017-11-17 | 2017-11-22 | 93 |  |
| 98 | 1.3.9.2 | Montáž OK na zemi | manual | 10d | 2018-02-05 | 2018-02-14 | 97, 94FS+4d |  |
| 99 | 1.3.9.3 | Postavení OK | manual | 3d | 2018-03-08 | 2018-03-10 | 97FS+28d, 95 |  |

| ID | WBS | Task | Type | Duration | Start | Finish | Predecessors | Total slack |
| --- | --- | --- | --- | --- | --- | --- | --- | --- |
| 100 | 1.3.10 | **p.b.86 - p.b.92** |  | 108d | 2017-11-27 | 2018-03-14 |  | 0d |
| 101 | 1.3.10.1 | Realizace základů | manual | 10d | 2017-11-27 | 2017-12-06 | 97FS+4d |  |
| 102 | 1.3.10.2 | Montáž OK na zemi | manual | 10d | 2018-02-19 | 2018-02-28 | 98FS+4d, 101 |  |
| 103 | 1.3.10.3 | Postavení OK | manual | 4d | 2018-03-11 | 2018-03-14 | 101FS+28d, 99 |  |
| 104 | 1.3.11 | **p.b.93 - p.b.102** |  | 131d | 2017-12-11 | 2018-04-20 |  | 0d |
| 105 | 1.3.11.1 | Realizace základů | manual | 10d | 2017-12-11 | 2017-12-20 | 101FS+4d |  |
| 106 | 1.3.11.2 | Montáž OK na zemi | manual | 10d | 2018-03-19 | 2018-03-28 | 105, 102FS+4d |  |
| 107 | 1.3.11.3 | Postavení OK | manual | 5d | 2018-04-16 | 2018-04-20 | 103FS+4d, 105FS+28d, 106 |  |
| 108 | 1.3.12 | **p.b.103 - p.b.112** |  | 122d | 2017-12-25 | 2018-04-25 |  | 0d |
| 109 | 1.3.12.1 | Realizace základů | manual | 10d | 2017-12-25 | 2018-01-03 | 105FS+4d |  |
| 110 | 1.3.12.2 | Montáž OK na zemi | manual | 10d | 2018-04-02 | 2018-04-11 | 106FS+4d, 109 |  |
| 111 | 1.3.12.3 | Postavení OK | manual | 5d | 2018-04-21 | 2018-04-25 | 107, 109SS+28d, 110 |  |
| 112 | 1.3.13 | **p.b.113 - p.b.122** |  | 63d | 2017-08-21 | 2017-10-22 |  | 0d |
| 113 | 1.3.13.1 | Realizace základů | manual | 10d | 2017-08-21 | 2017-08-30 |  |  |
| 114 | 1.3.13.2 | Montáž OK na zemi | manual | 10d | 2017-09-04 | 2017-09-13 |  |  |
| 115 | 1.3.13.3 | Postavení OK | manual | 7d | 2017-10-16 | 2017-10-22 | 113FS+28d |  |
| 116 | 1.3.14 | **p.b.123 - p.b.131** |  | 60d | 2017-09-04 | 2017-11-02 |  | 0d |
| 117 | 1.3.14.1 | Realizace základů | manual | 10d | 2017-09-04 | 2017-09-13 | 113FS+4d |  |
| 118 | 1.3.14.2 | Montáž OK na zemi | manual | 10d | 2017-09-18 | 2017-09-27 | 114FS+4d |  |
| 119 | 1.3.14.3 | Postavení OK | manual | 7d | 2017-10-23 | 2017-11-02 | 115, 117FS+28d |  |
| 120 | 1.3.15 | **p.b.132 - p.b.141** |  | 52d | 2017-09-18 | 2017-11-08 |  | 0d |
| 121 | 1.3.15.1 | Realizace základů | manual | 10d | 2017-09-18 | 2017-09-27 | 117FS+4d |  |
| 122 | 1.3.15.2 | Montáž OK na zemi | manual | 10d | 2017-10-02 | 2017-10-11 | 118FS+4d |  |
| 123 | 1.3.15.3 | Postavení OK | manual | 6d | 2017-11-03 | 2017-11-08 | 119, 121FS+28d |  |

| ID | WBS | Task | Type | Duration | Start | Finish | Predecessors | Total slack |
| --- | --- | --- | --- | --- | --- | --- | --- | --- |
| 124 | 1.3.16 | **p.b.142 - p.b.149** |  | 88d | 2017-10-02 | 2017-12-28 |  | 0d |
| 125 | 1.3.16.1 | Realizace základů | manual | 10d | 2017-10-02 | 2017-10-11 | 121FS+4d |  |
| 126 | 1.3.16.2 | Montáž OK na zemi | manual | 10d | 2017-11-13 | 2017-11-22 | 123FS+4d |  |
| 127 | 1.3.16.3 | Postavení OK | manual | 4d | 2017-12-25 | 2017-12-28 | 134FS+4d |  |
| 128 | 1.3.17 | **p.b.150 - p.b.155** |  | 77d | 2017-10-16 | 2017-12-31 |  | 0d |
| 129 | 1.3.17.1 | Realizace základů | manual | 7d | 2017-10-16 | 2017-10-22 | 125FS+4d |  |
| 130 | 1.3.17.2 | Montáž OK na zemi | manual | 10d | 2017-11-27 | 2017-12-06 | 126FS+4d |  |
| 131 | 1.3.17.3 | Postavení OK | manual | 3d | 2017-12-29 | 2017-12-31 | 127 |  |
| 132 | 1.3.18 | **p.b.156 - p.b.160** |  | 73d | 2017-10-23 | 2018-01-03 |  | 0d |
| 133 | 1.3.18.1 | Realizace základů | manual | 6d | 2017-10-23 | 2017-11-01 | 129 |  |
| 134 | 1.3.18.2 | Montáž OK na zemi | manual | 10d | 2017-12-11 | 2017-12-20 | 130FS+4d |  |
| 135 | 1.3.18.3 | Postavení OK | manual | 3d | 2018-01-01 | 2018-01-03 | 131 |  |
| 136 | 1.3.19 | **p.b.160 - p.b.165** |  | 99d | 2017-11-02 | 2018-02-08 |  | 0d |
| 137 | 1.3.19.1 | Realizace základů | manual | 7d | 2017-11-02 | 2017-11-08 | 133 |  |
| 138 | 1.3.19.2 | Montáž OK na zemi | manual | 10d | 2018-01-08 | 2018-01-17 | 135FS+4d |  |
| 139 | 1.3.19.3 | Postavení OK | manual | 4d | 2018-02-05 | 2018-02-08 | 135FS+4d, 142FS+4d |  |
| 140 | 1.3.20 | **p.b.166 - p.b.175** |  | 94d | 2017-11-13 | 2018-02-14 |  | 0d |
| 141 | 1.3.20.1 | Realizace základů | manual | 10d | 2017-11-13 | 2017-11-22 | 137FS+4d |  |
| 142 | 1.3.20.2 | Montáž OK na zemi | manual | 10d | 2018-01-22 | 2018-01-31 | 138FS+4d |  |
| 143 | 1.3.20.3 | Postavení OK | manual | 6d | 2018-02-09 | 2018-02-14 | 139 |  |
| 144 | 1.3.21 | **p.b.176 - p.b.183** |  | 117d | 2017-11-27 | 2018-03-23 |  | 0d |
| 145 | 1.3.21.1 | Realizace základů | manual | 10d | 2017-11-27 | 2017-12-06 | 141FS+4d |  |
| 146 | 1.3.21.2 | Montáž OK na zemi | manual | 10d | 2018-02-19 | 2018-02-28 | 143FS+4d |  |
| 147 | 1.3.21.3 | Postavení OK | manual | 5d | 2018-03-19 | 2018-03-23 | 143FS+4d |  |

| ID | WBS | Task | Type | Duration | Start | Finish | Predecessors | Total slack | Free slack | Constraint |
| --- | --- | --- | --- | --- | --- | --- | --- | --- | --- | --- |
| 148 | 1.3.22 | **p.b.184 - p.b.190** |  | 108d | 2017-12-11 | 2018-03-28 |  | 0d |  |  |
| 149 | 1.3.22.1 | Realizace základů | manual | 10d | 2017-12-11 | 2017-12-20 | 145FS+4d |  |  |  |
| 150 | 1.3.22.2 | Montáž OK na zemi | manual | 10d | 2018-03-05 | 2018-03-14 | 146FS+4d |  |  |  |
| 151 | 1.3.22.3 | Postavení OK | manual | 5d | 2018-03-24 | 2018-03-28 | 147 |  |  |  |
| 152 | 1.3.23 | **p.b.191 - p.b.199** |  | 131d | 2017-12-25 | 2018-05-04 |  | 0d |  |  |
| 153 | 1.3.23.1 | Realizace základů | manual | 10d | 2017-12-25 | 2018-01-03 | 149FS+4d |  |  |  |
| 154 | 1.3.23.2 | Montáž OK na zemi | manual | 10d | 2018-04-02 | 2018-04-11 | 151FS+4d |  |  |  |
| 155 | 1.3.23.3 | Postavení OK | manual | 5d | 2018-04-30 | 2018-05-04 | 153FS+28d, 151FS+4d, 158FS+4d |  |  |  |
| 156 | 1.3.24 | **p.b.200 - p.b.206** |  | 122d | 2018-01-08 | 2018-05-09 |  | 0d |  |  |
| 157 | 1.3.24.1 | Realizace základů | manual | 10d | 2018-01-08 | 2018-01-17 | 153FS+4d |  |  |  |
| 158 | 1.3.24.2 | Montáž OK na zemi | manual | 10d | 2018-04-16 | 2018-04-25 | 154FS+4d |  |  |  |
| 159 | 1.3.24.3 | Postavení OK | manual | 5d | 2018-05-05 | 2018-05-09 | 157SS+28d, 155 |  |  |  |
| 160 | 1.4 | **Montážní práce vodiče** |  | 66d | 2018-03-19 | 2018-05-23 |  | 7d |  |  |
| 161 | 1.4.1 | p.b.25 - p.b.26 |  | 1d | 2018-03-19 | 2018-03-19 |  | 28d | 0d | start no earlier than 2018-03-19 |
| 162 | 1.4.2 | p.b.27 - p.b.33 |  | 3d | 2018-03-20 | 2018-03-22 | 161 | 28d | 0d | start no earlier than 2017-08-17 |
| 163 | 1.4.3 | p.b.33 - p.b.40 |  | 3d | 2018-03-23 | 2018-03-25 | 162 | 28d | 0d | start no earlier than 2017-08-16 |
| 164 | 1.4.4 | p.b.40 - p.b.46 |  | 3d | 2018-03-26 | 2018-03-28 | 163 | 28d | 0d |  |
| 165 | 1.4.5 | p.b.46 - p.b.52 |  | 3d | 2018-04-02 | 2018-04-04 | 164FS+4d | 28d | 0d | start no earlier than 2017-11-07 |
| 166 | 1.4.6 | p.b.52 - p.b.59 |  | 3d | 2018-04-05 | 2018-04-07 | 165 | 28d | 0d |  |
| 167 | 1.4.7 | p.b.59 - p.b.69 |  | 4d | 2018-04-08 | 2018-04-11 | 166 | 28d | 0d | start no earlier than 2017-11-15 |
| 168 | 1.4.8 | p.b.69 - p.b.76 |  | 4d | 2018-04-16 | 2018-04-19 | 167FS+4d | 28d | 0d |  |
| 169 | 1.4.9 | p.b.76 - p.b.80 |  | 3d | 2018-04-20 | 2018-04-22 | 168 | 28d | 0d | start no earlier than 2017-11-07 |
| 170 | 1.4.10 | p.b.80 - p.b.85 |  | 3d | 2018-04-23 | 2018-04-25 | 169 | 28d | 0d | start no earlier than 2017-11-21 |
| 171 | 1.4.11 | p.b.85 - p.b.92 |  | 3d | 2018-04-30 | 2018-05-02 | 170FS+4d | 28d | 0d | start no earlier than 2018-03-23 |
| 172 | 1.4.12 | p.b.92 - p.b.102 | manual | 3d | 2018-05-03 | 2018-05-05 | 171 |  |  |  |
| 173 | 1.4.13 | p.b.102 - p.b.112 | manual | 3d | 2018-05-06 | 2018-05-08 | 172 |  |  |  |
| 174 | 1.4.14 | p.b.112 - p.b.113 | manual | 1d | 2018-05-09 | 2018-05-09 | 173 |  |  |  |
| 175 | 1.4.15 | p.b.113 - p.b.122 | manual | 3d | 2018-04-02 | 2018-04-04 |  |  |  |  |
| 176 | 1.4.16 | p.b.122 - p.b.131 | manual | 3d | 2018-04-05 | 2018-04-07 | 175 |  |  |  |
| 177 | 1.4.17 | p.b.131 - p.b.132 | manual | 1d | 2018-04-08 | 2018-04-08 | 176 |  |  |  |
| 178 | 1.4.18 | p.b.132 - p.b.141 | manual | 3d | 2018-04-09 | 2018-04-11 | 177 |  |  |  |
| 179 | 1.4.19 | p.b.141 - p.b.142 | manual | 3d | 2018-04-16 | 2018-04-18 | 178FS+4d |  |  |  |
| 180 | 1.4.20 | p.b.142 - p.b.149 | manual | 2d | 2018-04-19 | 2018-04-20 | 179 |  |  |  |
| 181 | 1.4.21 | p.b.149 - p.b.155 | manual | 3d | 2018-04-21 | 2018-04-23 | 180 |  |  |  |
| 182 | 1.4.22 | p.b.155 - p.b.160 | manual | 2d | 2018-04-24 | 2018-04-25 | 181 |  |  |  |
| 183 | 1.4.23 | p.b.160 - p.b.165 | manual | 2d | 2018-04-30 | 2018-05-01 | 182 |  |  |  |
| 184 | 1.4.24 | p.b.165 - p.b.175 | manual | 3d | 2018-05-02 | 2018-05-04 | 183 |  |  |  |
| 185 | 1.4.25 | p.b.175 - p.b.176 | manual | 2d | 2018-05-05 | 2018-05-06 | 184 |  |  |  |
| 186 | 1.4.26 | p.b.176 - p.b.177 | manual | 1d | 2018-05-07 | 2018-05-07 | 185 |  |  |  |
| 187 | 1.4.27 | p.b.177 - p.b.183 | manual | 2d | 2018-05-08 | 2018-05-09 | 186 |  |  |  |
| 188 | 1.4.28 | p.b.183 - p.b.190 | manual | 2d | 2018-05-14 | 2018-05-15 | 187FS+4d |  |  |  |
| 189 | 1.4.29 | p.b.190 - p.b.199 | manual | 3d | 2018-05-16 | 2018-05-18 | 188 |  |  |  |
| 190 | 1.4.30 | p.b.199 - p.b.200 | manual | 1d | 2018-05-19 | 2018-05-19 | 189 |  |  |  |
| 191 | 1.4.31 | p.b.200 - p.b.205 | manual | 2d | 2018-05-20 | 2018-05-21 | 190 |  |  |  |
| 192 | 1.4.32 | p.b.205 - p.b.206 | manual | 1d | 2018-05-22 | 2018-05-22 | 191 |  |  |  |
| 193 | 1.4.33 | p.b.206 - p.b.portál Telč | manual | 1d | 2018-05-23 | 2018-05-23 | 192 |  |  |  |

| ID | WBS | Task | Type | Duration | Start | Finish | Predecessors | Total slack | Constraint |
| --- | --- | --- | --- | --- | --- | --- | --- | --- | --- |
| 194 | 1.5 | **Montážní práce KZL** |  | 10d | 2018-05-28 | 2018-06-06 |  | 0d |  |
| 195 | 1.5.1 | p.b.25 - p.b.46 |  | 2d | 2018-05-28 | 2018-05-29 |  | 0d | start no earlier than 2018-05-28 |
| 196 | 1.5.2 | p.b.46 - p.b.69 |  | 2d | 2018-05-30 | 2018-05-31 | 195 | 0d |  |
| 197 | 1.5.3 | p.b.69 - p.b.92 |  | 3d | 2018-06-01 | 2018-06-03 | 196 | 0d |  |
| 198 | 1.5.4 | p.b.92 - p.b.113 |  | 3d | 2018-06-04 | 2018-06-06 | 197 | 0d |  |
| 199 | 1.5.5 | p.b.113 - p.b.141 |  | 3d | 2018-05-28 | 2018-05-30 |  | 0d | start no earlier than 2018-05-28 |
| 200 | 1.5.6 | p.b.141 - p.b.160 |  | 2d | 2018-05-31 | 2018-06-01 | 199 | 0d |  |
| 201 | 1.5.7 | p.b.160 - p.b.175 | manual | 2d | 2018-06-02 | 2018-06-03 | 200 |  |  |
| 202 | 1.5.8 | p.b.175 - p.b.190 | manual | 2d | 2018-06-04 | 2018-06-05 | 201 |  |  |
| 203 | 1.5.9 | p.b.190 - portál Telč | manual | 1d | 2018-06-06 | 2018-06-06 | 202 |  |  |
| 204 | 1.6 | **Vypínaní** |  | 300d? | 2017-08-11 | 2018-06-06 |  | 0d |  |
| 205 | 1.6.1 | V5522 | manual | 300d | 2017-08-11 | 2018-06-06 |  |  |  |
| 206 | 1.6.2 | V5523 | manual | 3d | 2017-08-11 | 2018-05-28 |  |  |  |
| 207 | 1.6.3 | V5521 | manual | 3d | 2017-09-25 | 2018-06-06 |  |  |  |
| 208 | 1.6.4 | 22kV | manual | 1d? | 2017-08-11 | 2017-08-11 |  |  |  |
| 209 | 1.6.5 | 400kV | manual | 1d? | 2017-08-11 | 2017-08-11 |  |  |  |
